Schedule from MS Project, 2002-01-01 to 2003-07-02, 24 hours a day.
NAMA SA

## Calendars

- 24 Hours: Mon-Sun 00:00-24:00.

## Resources

| Resource |
| --- |
| Εργοδότης |
| Προιστάμενη Αρχή |
| Διευθύνουσα Υπηρεσία |
| Γενικός Μελετητής |
| Αλλοι τοπικοί φορείς |
| Μελετητές |
| Γεωλόγος |
| Δνση Χωροταξίας ΥΠΕΧΩΔΕ |
| ΓΓ Περίφέρειας |
| Δνση Χωροταξίας (Κεντρική ή Περιφερειακή) |
| Υπουργείο Γεωργείας |
| ΥΠΠΟ |
| ΥΠΕΧΩΔΕ/Περιβάλλον |
| Τοπογράφος |
| Γεωτεχνικός |
| Κυκλοφοριολόγος |
| Μελετητης Περιβαλλοντολόγος |
| Δνση Περιβαλλοντικού Σχεδιασμού |
| Δνση Περιβαλλοντος και Χωροταξίας Γενικής Γραμματείας της Περιφέρειας |
| Νομαρχιακό Συμβούλιο |
| Ενδιαφερόμενο Κοινό |
| Εδαφοτεχνικός Μελετητης |
| Συγκοινωνιλόγος Μηχανικός |
| Κύριος του Έργου |
| Γενικός Μελετητής(Ειδικός Συγκοινωνιολόγος) |
| Μελετήτής Οικονομολόγος |
| Δνση Χωροταξίας ΥΠΕΧΩΔΕ ή ΔΙΠΕΧΩ ΓΓ Περίφέρειας |
| ΥΠΕΧΩΔΕ |
| Ηλεκτρολόγος-Μηχανολόγος |
| Συναρμόδιες Υπηρεσίες |
| Ειδικό Εργαστήριο |
| Επιτροπή καθορισμού της Γραμμής Αιγιαλού & Παραλίας |
| ΔΤΥΝΑ (Δνση Τεχνικών Υπηρεσιών της αρμόδιας Νομαρχιακής Αυτοδιοίκησης) |
| Κτηματική Υπηρεσία του Νομού |
| Υπ. Οκονομικών |
| ΥΕΝ |
| ΓΕΝ |
| Πολεοδομική Αρχή |
| EYΠΕ/ΥΠΕΧΩΔΕ ή ΔΙΠΕΧΩ Περιφέρειας |

## Schedule

| ID | WBS | Task | Type | Duration | Start | Finish | Predecessors | Baseline start | Baseline finish | Baseline duration | Total slack | Free slack | Resources | Work | Text1 |
| --- | --- | --- | --- | --- | --- | --- | --- | --- | --- | --- | --- | --- | --- | --- | --- |
| 1 | 1 | **ΣΤΑΔΙΟ Ι: Προκαταρκτικός Προγραμματισμός Έργου** |  | 119d | 2002-01-01 | 2002-04-30 |  |  |  |  | 0d |  |  | 2136h | 4M |
| 2 | 1.1 | Μελέτη Κοινωνικής και Πολιτικής Σκοπιμότητας |  | 31d | 2002-01-01 | 2002-02-01 |  |  |  |  | 0d |  | Εργοδότης | 744h | 1M |
| 3 | 1.2 | **Προκαταρκτικά Στοιχεία έργου** |  | 88d | 2002-02-01 | 2002-04-30 | 2 |  |  |  | 0d |  |  | 1392h | 3M |
| 4 | 1.2.1 | Προσδιορισμός του Μεγέθους και των Λειτουργιών |  | 28d | 2002-02-01 | 2002-03-01 |  |  |  |  | 0d |  | Εργοδότης | 672h | 1M |
| 5 | 1.2.2 | Προυπολογισμός - Χρηματοδότηση |  | 60d | 2002-03-01 | 2002-04-30 | 4 |  |  |  | 0d |  |  |  | 2Μ |
| 6 | 1.2.3 | Προκαταρκτική Μελέτη Έρευνας Άγοράς |  | 30d | 2002-03-31 | 2002-04-30 | 5FS-30d |  |  |  | 0d |  | Εργοδότης | 720h | 1M |
| 7 | 2 | Εγκριση Προγράμματος Εκτέλεσης Έργου |  | 31d | 2002-04-30 | 2002-05-31 | 1 |  |  |  | 0d |  | Εργοδότης | 744h | 1M |
| 8 | 3 | **ΣΤΑΔΙΟ ΙΙ Προκαταρκτικές και Υποστηρικτικές Μελέτες** |  | 397d | 2002-05-31 | 2003-07-02 | 7 |  |  |  | 0d |  |  | 25968h | 18Μ |
| 9 | 3.1 | **Διαδικασία Ανάθεσης και Επίβλεψης Μελέτης** |  | 182d | 2002-05-31 | 2002-11-29 |  |  |  |  | 0d |  |  | 3744h | 6Μ |
| 10 | 3.1.1 | **Διαδικασία Επιλογής Μελετητή** |  | 152d | 2002-05-31 | 2002-10-30 |  |  |  |  | 0d |  |  | 864h | 5Μ |
| 11 | 3.1.1.1 | Δημοσίευση Προκήρυξης Μελέτης |  | 44d | 2002-05-31 | 2002-07-14 |  | 2002-01-11 | 2002-01-11 | 0.33d? | 0d |  | Εργοδότης | 288h | 1.5Μ |
| 12 | 3.1.1.2 | Αξιολόγηση Υποψήφιων Μελετητών |  | 16d | 2002-07-14 | 2002-07-30 | 11 | 2002-02-10 | 2002-03-12 | 30d | 0d |  | Εργοδότης | 112h | 0.5Μ |
| 13 | 3.1.1.3 | Επιλογή Μελετητή |  | 15d | 2002-07-30 | 2002-08-14 | 12 | 2002-03-12 | 2002-03-27 | 15d | 0d |  | Εργοδότης | 64h | 0.5Μ |
| 14 | 3.1.1.4 | Κοινοποίηση Απόφασης Ανάθεσης |  | 15d | 2002-08-14 | 2002-08-29 | 13 | 2002-03-27 | 2002-04-11 | 15d | 0d |  | Εργοδότης | 48h | 0.5Μ |
| 15 | 3.1.1.5 | Διαδικασία Ενστάσεων |  | 46d | 2002-08-29 | 2002-10-14 | 14 | 2002-04-11 | 2002-06-30 | 80d | 0d |  | Εργοδότης | 288h | 1.5Μ |
| 16 | 3.1.1.6 | Ανάθεση Μελέτης |  | 16d | 2002-10-14 | 2002-10-30 | 15 | 2002-06-30 | 2002-06-30 | 0d? | 0d |  | Εργοδότης | 64h | 0.5Μ |
| 17 | 3.1.2 | Κατάρτιση και Υπογραφή Σύμβασης |  | 30d | 2002-10-30 | 2002-11-29 | 16 |  |  |  | 0d |  | Εργοδότης; Προιστάμενη Αρχή; Διευθύνουσα Υπηρεσία; Γενικός Μελετητής | 2880h | 1Μ |
| 18 | 3.2 | Επίβλεψη Μελέτης |  | 215d | 2002-11-29 | 2003-07-02 | 17 |  |  |  | 0d |  | Διευθύνουσα Υπηρεσία; Γενικός Μελετητής | 10320h | 7Μ |
| 19 | 3.3 | Εποπτεία Μελέτης |  | 215d | 2002-11-29 | 2003-07-02 | 18SS |  |  |  | 0d |  | Προιστάμενη Αρχή; Γενικός Μελετητής | 10320h | 7Μ |
| 20 | 3.4 | **Προκαταρκτικές και Υποστηρικτικές Μελέτες** |  | 31d | 2002-11-29 | 2002-12-30 | 17 |  |  |  | 0d |  |  | 1584h | 1Μ |
| 21 | 3.4.1 | Εντολή Έναρξης Σταδίου Ι | milestone | 0d | 2002-11-29 | 2002-11-29 |  |  |  |  | 184d | 0d | Εργοδότης |  | 0Μ |
| 22 | 3.4.2 | Αναγνώριση Έργου - Συγκέντρωση Στοιχείων |  | 31d | 2002-11-29 | 2002-12-30 | 21 |  |  |  | 184d |  | Διευθύνουσα Υπηρεσία; Γενικός Μελετητής; Αλλοι τοπικοί φορείς | 528h | 1Μ |
| 23 | 3.4.3 | Εκπόνηση Προκαταρκτικής Μελέτης |  | 31d | 2002-11-29 | 2002-12-30 |  |  |  |  | 0d |  | Διευθύνουσα Υπηρεσία; Γενικός Μελετητής | 1056h | 1Μ |
| 24 | 4 | Εγκριση Σταδίου ΙΙ |  | 31d | 2002-12-30 | 2003-01-30 | 23 |  |  |  | 0d |  | Εργοδότης | 168h | 1Μ |

| ID | WBS | Task | Type | Duration | Start | Finish | Predecessors | Total slack | Resources | Work | Text1 |
| --- | --- | --- | --- | --- | --- | --- | --- | --- | --- | --- | --- |
| 25 | 5 | **ΣΤΑΔΙΟ ΙΙΙ : Τεχνικές Προδιαγραφές - Τεύχη Δημοπράτησης** |  | 122d | 2003-01-30 | 2003-06-01 | 24 | 0d |  | 3968h | 4Μ |
| 26 | 5.1 | Εντολή Έναρξης Σταδίου ΙΙΙ | milestone | 0d | 2003-01-30 | 2003-01-30 |  | 0d | Εργοδότης |  | 0Μ |
| 27 | 5.2 | Εκπόνηση Προμελέτών - Τεχνικών Προδιαγραφών |  | 61d | 2003-01-30 | 2003-04-01 | 26 | 0d | Διευθύνουσα Υπηρεσία; Γενικός Μελετητής | 1040h | 2Μ |
| 28 | 5.3 | Σύνταξη Τευχών Δημοπράτησης |  | 61d | 2003-04-01 | 2003-06-01 | 27 | 0d | Γενικός Μελετητής; Διευθύνουσα Υπηρεσία | 2928h | 2M |
| 29 | 6 | Εγκριση Σταδίου ΙΙΙ (Παραλαβή - Εγκριση Προμελετών & Τευχών Δημοπράτησης) |  | 31d | 2003-06-01 | 2003-07-02 | 25, 28 | 0d | Διευθύνουσα Υπηρεσία; Συναρμόδιες Υπηρεσίες | 1488h | 1Μ |
