Schedule from MS Project, 2002-01-01 to 2004-01-31, 24 hours a day.
NAMA SA

## Calendars

- 24 Hours: Mon-Sun 00:00-24:00.

## Resources

| Resource |
| --- |
| Εργοδότης |
| Προιστάμενη Αρχή |
| Διευθύνουσα Υπηρεσία |
| Γενικός Μελετητής |
| Αλλοι τοπικοί φορείς |
| Μελετητές |
| Γεωλόγος |
| Δνση Χωροταξίας ΥΠΕΧΩΔΕ |
| ΓΓ Περίφέρειας |
| Δνση Χωροταξίας (Κεντρική ή Περιφ/κή) |
| Υπουργείο Γεωργείας |
| ΥΠΠΟ |
| ΥΠΕΧΩΔΕ/Περιβάλλον |
| Τοπογράφος |
| Γεωτεχνικός |
| Κυκλοφοριολόγος |
| Μελετητης Περιβαλλοντολόγος |
| Δνση Περιβαλλοντικού Σχεδιασμού |
| Δνση Περιβαλλοντος και Χωροταξίας Γενικής Γραμματείας της Περιφέρειας |
| Νομαρχιακό Συμβούλιο |
| Ενδιαφερόμενο Κοινό |
| Εδαφοτεχνικός Μελετητης |
| Συγκοινωνιλόγος Μηχανικός |
| Κύριος του Έργου |
| Γενικός Μελετητής(Ειδικός Συγκοινωνιολόγος) |
| Μελετήτής Οικονομολόγος |
| Δνση Χωροταξίας ΥΠΕΧΩΔΕ ή ΔΙΠΕΧΩ ΓΓ Περίφέρειας |
| ΥΠΕΧΩΔΕ |
| Ηλεκτρολόγος-Μηχανολόγος |
| Συναρμόδιες Υπηρεσίες |
| Ειδικό Εργαστήριο |
| Επιτροπή καθορισμού της Γραμμής Αιγιαλού & Παραλίας |
| ΔΤΥΝΑ (Δνση Τεχνικών Υπηρεσιών της αρμόδιας Νομαρχιακής Αυτοδιοίκησης) |
| Κτηματική Υπηρεσία του Νομού |
| Υπ. Οκονομικών |
| ΥΕΝ |
| ΓΕΝ |
| Πολεοδομική Αρχή |
| ΕΥΠΕ |
| ΕΥΠΕ/ΥΠΕΧΩΔΕ ή ΔΙΠΕΧΩ ΓΓ Περιφέρειας |
| Συναρμόδια Υπουργεία |
| Συναρμόδιοι Υπουργοί |
| ή Δ/νση Περιβάλλοντος Νομαρχίας |
| Νομάρχης |

## Schedule

| ID | WBS | Task | Type | Duration | Start | Finish | Predecessors | Baseline start | Baseline finish | Baseline duration | Total slack | Free slack | Resources | Work | Text1 |
| --- | --- | --- | --- | --- | --- | --- | --- | --- | --- | --- | --- | --- | --- | --- | --- |
| 1 | 1 | **ΣΤΑΔΙΟ Ι: Προκαταρκτικός Προγραμματισμός Έργου** |  | 121d | 2002-01-01 | 2002-05-02 |  |  |  |  | 0d |  |  | 4368h | 4M |
| 2 | 1.1 | Μελέτη Κοινωνικής και Πολιτικής Σκοπιμότητας |  | 31d | 2002-01-01 | 2002-02-01 |  |  |  |  | 0d |  | Εργοδότης | 744h | 1M |
| 3 | 1.2 | **Προκαταρκτικά Στοιχεία έργου** |  | 90d | 2002-02-01 | 2002-05-02 | 2 |  |  |  | 0d |  |  | 3624h | 3M |
| 4 | 1.2.1 | Προσδιορισμός του Μεγέθους και των Λειτουργιών |  | 31d | 2002-02-01 | 2002-03-04 |  |  |  |  | 59d |  | Εργοδότης | 744h | 1M |
| 5 | 1.2.2 | **Χωροθέτηση του Έργου** |  | 90d | 2002-02-01 | 2002-05-02 |  |  |  |  | 0d |  |  | 2160h | 3M |
| 6 | 1.2.2.1 | Εξεύρεση Χώρου |  | 45d | 2002-02-01 | 2002-03-18 |  |  |  |  | 0d |  | Εργοδότης | 1080h | 1.5M |
| 7 | 1.2.2.2 | Οικιστική Καταλληλότητα |  | 45d | 2002-03-18 | 2002-05-02 | 6 |  |  |  | 0d |  | Εργοδότης | 1080h | 1.5M |
| 8 | 1.2.3 | Προϋπολογισμός και Πηγές Χρηματοδότησης |  | 30d | 2002-02-01 | 2002-03-03 |  |  |  |  | 60d |  | Εργοδότης | 720h | 1M |
| 9 | 2 | Εγκριση Προγράμματος Εκτέλεσης Έργου |  | 30d | 2002-05-02 | 2002-06-01 | 1 |  |  |  | 0d |  | Εργοδότης | 720h | 1M |
| 10 | 3 | **ΣΤΑΔΙΟ ΙΙ: Προκαταρκτικές και Υποστηρικτικές Μελέτες** |  | 608d | 2002-06-01 | 2004-01-30 | 9 |  |  |  | 0d |  |  | 58592h | 21Μ |
| 11 | 3.1 | **Διαδικασία Ανάθεσης και Επίβλεψης Μελέτης** |  | 182d | 2002-06-01 | 2002-11-30 |  |  |  |  | 0d |  |  | 3744h | 6Μ |
| 12 | 3.1.1 | **Διαδικασία Επιλογής Μελετητή** |  | 152d | 2002-06-01 | 2002-10-31 |  |  |  |  | 0d |  |  | 864h | 5Μ |
| 13 | 3.1.1.1 | Δημοσίευση Προκήρυξης Μελέτης |  | 44d | 2002-06-01 | 2002-07-15 |  | 2002-01-11 | 2002-01-11 | 0.33d? | 0d |  | Εργοδότης | 288h | 1.5Μ |
| 14 | 3.1.1.2 | Αξιολόγηση Υποψήφιων Μελετητών |  | 16d | 2002-07-15 | 2002-07-31 | 13 | 2002-02-10 | 2002-03-12 | 30d | 0d |  | Εργοδότης | 112h | 0.5Μ |
| 15 | 3.1.1.3 | Επιλογή Μελετητή |  | 15d | 2002-07-31 | 2002-08-15 | 14 | 2002-03-12 | 2002-03-27 | 15d | 0d |  | Εργοδότης | 64h | 0.5Μ |
| 16 | 3.1.1.4 | Κοινοποίηση Απόφασης Ανάθεσης |  | 15d | 2002-08-15 | 2002-08-30 | 15 | 2002-03-27 | 2002-04-11 | 15d | 0d |  | Εργοδότης | 48h | 0.5Μ |
| 17 | 3.1.1.5 | Διαδικασία Ενστάσεων |  | 46d | 2002-08-30 | 2002-10-15 | 16 | 2002-04-11 | 2002-06-30 | 80d | 0d |  | Εργοδότης | 288h | 1.5Μ |
| 18 | 3.1.1.6 | Ανάθεση Μελέτης |  | 16d | 2002-10-15 | 2002-10-31 | 17 | 2002-06-30 | 2002-06-30 | 0d? | 0d |  | Εργοδότης | 64h | 0.5Μ |
| 19 | 3.1.2 | Κατάρτιση και Υπογραφή Σύμβασης |  | 30d | 2002-10-31 | 2002-11-30 | 18 |  |  |  | 0d |  | Εργοδότης; Προιστάμενη Αρχή; Διευθύνουσα Υπηρεσία; Γενικός Μελετητής | 2880h | 1Μ |
| 20 | 3.2 | Επίβλεψη Μελέτης |  | 426d | 2002-11-30 | 2004-01-30 | 19 |  |  |  | 1d | 0d | Διευθύνουσα Υπηρεσία; Γενικός Μελετητής | 20448h | 14Μ |
| 21 | 3.3 | Εποπτεία Μελέτης |  | 426d | 2002-11-30 | 2004-01-30 | 20SS |  |  |  | 1d |  | Προιστάμενη Αρχή; Γενικός Μελετητής | 20448h | 14Μ |
| 22 | 3.4 | **Προκαταρκτικές και Υποστηρικτικές Μελέτες** |  | 121d | 2002-11-30 | 2003-03-31 | 19 |  |  |  | 0d |  |  | 8336h | 4Μ |
| 23 | 3.4.1 | Εντολή Έναρξης Σταδίου Ι | milestone | 0d | 2002-11-30 | 2002-11-30 |  |  |  |  | 396d | 0d | Εργοδότης |  | 0Μ |
| 24 | 3.4.2 | Αναγνώριση Έργου - Συγκέντρωση Στοιχείων |  | 31d | 2002-11-30 | 2002-12-31 | 23 |  |  |  | 396d |  | Διευθύνουσα Υπηρεσία; Γενικός Μελετητής; Αλλοι τοπικοί φορείς | 528h | 1Μ |
| 25 | 3.4.3 | Εκπόνηση Προκαταρκτικής Μελέτης |  | 31d | 2002-11-30 | 2002-12-31 |  |  |  |  | 0d |  | Διευθύνουσα Υπηρεσία; Γενικός Μελετητής | 1056h | 1Μ |

| ID | WBS | Task | Type | Duration | Start | Finish | Predecessors | Baseline start | Baseline finish | Baseline duration | Total slack | Constraint | Resources | Work | Text1 |
| --- | --- | --- | --- | --- | --- | --- | --- | --- | --- | --- | --- | --- | --- | --- | --- |
| 26 | 3.4.4 | **Εκπόνηση Υποστηρικτικών Μελετών** |  | 90d | 2002-12-31 | 2003-03-31 | 25 |  |  |  | 0d |  | Διευθύνουσα Υπηρεσία; Γενικός Μελετητής | 6752h | 3Μ |
| 27 | 3.4.4.1 | Εκτέλεση Γεωτεχνικών Ερευνών |  | 60d | 2002-12-31 | 2003-03-01 |  |  |  |  | 30d |  | Διευθύνουσα Υπηρεσία; Εδαφοτεχνικός Μελετητης | 672h | 2Μ |
| 28 | 3.4.4.2 | Προμέλετη Περιβαλλοντικών Επιπτώσεων |  | 31d | 2002-12-31 | 2003-01-31 | 25 |  |  |  | 59d |  | Διευθύνουσα Υπηρεσία; Γενικός Μελετητής | 352h | 1Μ |
| 29 | 3.4.4.3 | Εκπόνηση Οικονομοτεχνικής Μελέτης |  | 62d | 2002-12-31 | 2003-03-03 |  |  |  |  | 28d |  | Διευθύνουσα Υπηρεσία; Γενικός Μελετητής; Μελετήτής Οικονομολόγος | 1056h | 2Μ |
| 30 | 3.4.4.4 | Λοιπές Υποστηρικτικές Μελέτες |  | 90d | 2002-12-31 | 2003-03-31 |  |  |  |  | 0d |  | Διευθύνουσα Υπηρεσία; Γενικός Μελετητής | 4320h | 3Μ |
| 31 | 3.5 | Εκπόνηση Προμελέτης Περιβαλλοντικών Επιπτώσεων (Φ.Π.Χ.) ή/και Φακέλου Τροποποίησης Γεν. Πολ. Σχεδιασμού |  | 31d | 2003-03-01 | 2003-04-01 | 26FS-30d |  |  |  | 0d |  | Διευθύνουσα Υπηρεσία; Γενικός Μελετητής | 1488h | 1Μ |
| 32 | 3.6 | **Διαδικασίες Έκδοσης Προκαταρκτικής Περιβαλλοντικής Εκτίμησης και Αξιολόγησης (Π.Χ.)** |  | 90d | 2003-04-01 | 2003-06-30 | 31 |  |  |  | 0d |  |  | 1944h | 3Μ |
| 33 | 3.6.1 | Παραλαβή Π.Π.Ε.(Φ.Π.Χ.) - Έλεγχος - Υποβολή |  | 15d | 2003-04-01 | 2003-04-16 |  | 2003-03-01 | 2003-03-04 | 3d | 0d |  | Διευθύνουσα Υπηρεσία | 80h | 0.5Μ |
| 34 | 3.6.2 | Παραλαβή Π.Π.Ε.(Φ.Π.Χ.) - Γνωμοδοτήσεις Συναρμοδίων |  | 60d | 2003-04-16 | 2003-06-15 | 33 |  |  |  | 0d |  | ΕΥΠΕ/ΥΠΕΧΩΔΕ ή ΔΙΠΕΧΩ ΓΓ Περιφέρειας; Συναρμόδιες Υπηρεσίες | 1784h | 2Μ |
| 35 | 3.6.3 | Έκδοση Προκαταρκτικής Περιβαλλοντικής Εκτίμησης και Αξιολόγησης (Π.Χ.) |  | 15d | 2003-06-15 | 2003-06-30 | 34 | 2003-03-25 | 2003-03-31 | 6d | 0d |  | ΕΥΠΕ/ΥΠΕΧΩΔΕ ή ΔΙΠΕΧΩ ΓΓ Περιφέρειας | 80h | 0.5Μ |
| 36 | 3.7 | Διαδικασία Τροποποίησης του Γενικού Πολεοδομικού Σχεδιασμού |  | 91d | 2003-04-01 | 2003-07-01 | 32SS |  |  |  | 214d |  | Πολεοδομική Αρχή | 2184h | 3Μ |
| 37 | 4 | Εγκριση Σταδίου ΙΙ |  | 31d | 2003-06-30 | 2003-07-31 | 35 |  |  |  | 0d |  | Εργοδότης | 168h | 1Μ |
| 38 | 5 | **ΣΤΑΔΙΟ ΙΙΙ : Προμελέτες και Αδειοδοτήσεις** |  | 184d | 2003-07-31 | 2004-01-31 | 37 |  |  |  | 0d |  |  | 7672h | 5Μ |
| 39 | 5.1 | Εντολή Έναρξης Σταδίου ΙΙΙ | milestone | 0d | 2003-07-31 | 2003-07-31 |  |  |  |  | 0d |  | Εργοδότης |  | 0Μ |
| 40 | 5.2 | Εκπόνηση Προμελέτών |  | 122d | 2003-07-31 | 2003-11-30 | 39 |  |  |  | 0d |  | Διευθύνουσα Υπηρεσία; Γενικός Μελετητής | 1040h | 4M |
| 41 | 5.3 | Εκπόνηση Μελέτης Περιβαλλοντικών Επιπτώσεων-Μ.Π.Ε. |  | 30d | 2003-07-31 | 2003-08-30 | 40SS |  |  |  | 0d |  | Γενικός Μελετητής | 720h | 1Μ |
| 42 | 5.4 | **Διαδικασίες Έκδοσης Απόφασης Έγκρισης Περιβαλλοντικών Όρων** |  | 124d | 2003-08-30 | 2004-01-01 | 35, 41 |  |  |  | 0d |  |  | 1496h | 4Μ |
| 43 | 5.4.1 | Παραλάβή Μ.Π.Ε.-Έλεγχος-Υποβολή |  | 15d | 2003-08-30 | 2003-09-14 |  | 2003-11-26 | 2003-12-11 | 15d | 0d |  | Διευθύνουσα Υπηρεσία | 88h | 0.5Μ |
| 44 | 5.4.2 | Παραλαβή της Μ.Π.Ε.-Έλεγχος-Διαβίβαση |  | 15d | 2003-09-14 | 2003-09-29 | 43 | 2003-12-11 | 2004-01-10 | 30d | 0d |  | ΕΥΠΕ/ΥΠΕΧΩΔΕ ή ΔΙΠΕΧΩ ΓΓ Περιφέρειας | 80h | 0.5Μ |
| 45 | 5.4.3 | Παραλαβή της Μ.Π.Ε.-Γνωμοδότηση-Διαβίβαση |  | 15d | 2003-09-29 | 2003-10-14 | 44 | 2003-12-26 | 2004-01-10 | 15d | 79d |  | Συναρμόδια Υπουργεία | 80h | 0.5Μ |
| 46 | 5.4.4 | Νομαρχιακό Συμβούλιο: Παραλαβή-Δημοσίευση Ανάρτηση ΜΠΕ |  | 15d | 2003-09-29 | 2003-10-14 | 44 | 2004-01-10 | 2004-02-09 | 30d | 0d |  | Νομαρχιακό Συμβούλιο | 168h | 0.5Μ |
| 47 | 5.4.5 | Διατύπωση Απόψεων - Αντιρρήσεων - Προτάσεων |  | 15d | 2003-10-07 | 2003-10-22 | 46FS-7d | 2004-01-25 | 2004-02-14 | 20d | 0d |  | Ενδιαφερόμενο Κοινό | 112h | 0.5Μ |
| 48 | 5.4.6 | Νομαρχιακό Συμβούλιο: Κριτική Άποψη Διαβίβαση |  | 15d | 2003-10-16 | 2003-10-31 | 47FS-6d | 2004-02-14 | 2004-02-29 | 15d | 0d |  | Νομαρχιακό Συμβούλιο | 88h | 0.5Μ |
| 49 | 5.4.7 | Σύνταξη Σχεδίου Απόφασης Έγκρισης Περιβαλλοντικών Όρων |  | 30d | 2003-10-31 | 2003-11-30 | 48 | 2004-02-29 | 2004-03-15 | 15d | 0d |  | ΕΥΠΕ/ΥΠΕΧΩΔΕ ή ΔΙΠΕΧΩ ΓΓ Περιφέρειας; ή Δ/νση Περιβάλλοντος Νομαρχίας | 336h | 1Μ |
| 50 | 5.4.8 | Υπογραφή Υπουργών ή Γ.Γ. Περιφέρειας ή Νομαρχών |  | 16d | 2003-11-30 | 2003-12-16 | 49 | 2004-03-15 | 2004-03-31 | 16d | 0d |  | ΥΠΕΧΩΔΕ; ΓΓ Περίφέρειας; Συναρμόδιοι Υπουργοί; Νομάρχης | 352h | 0.5Μ |
| 51 | 5.4.9 | Έκδοση Απόφασης Έγκρισης Περιβαλλοντικών Όρων |  | 16d | 2003-12-16 | 2004-01-01 | 50 | 2004-03-31 | 2004-03-31 | 0d? | 0d |  | ΕΥΠΕ/ΥΠΕΧΩΔΕ ή ΔΙΠΕΧΩ ΓΓ Περιφέρειας; ή Δ/νση Περιβάλλοντος Νομαρχίας | 192h | 0.5Μ |
| 52 | 5.5 | Σύνταξη Τευχών Δημοπράτησης |  | 62d | 2003-10-31 | 2004-01-01 | 42FF |  |  |  | 0d | start no earlier than 2003-10-26 | Γενικός Μελετητής; Διευθύνουσα Υπηρεσία | 2976h | 2M |
| 53 | 5.6 | Εγκριση Σταδίου ΙΙΙ (Παραλαβή - Εγκριση Προμελετών & Τευχών Δημοπράτησης) |  | 30d | 2004-01-01 | 2004-01-31 | 52 |  |  |  | 0d |  | Διευθύνουσα Υπηρεσία; Συναρμόδιες Υπηρεσίες | 1440h | 1Μ |
